# ITP-4 v1.5 - iProject Management - Project Resources and Costs

Schedule from MS Project, 2014-09-08 to 2015-02-13, costs in $.
UMUC Vet Clinic

## Calendars

- Standard: Mon-Fri 08:00-12:00, 13:00-17:00; Sat-Sun off. Exceptions (off unless hours are given): 2014-09-13 to 2014-09-14 08:00-12:00, 13:00-17:00, 2014-09-20 08:00-12:00, 13:00-17:00, 2014-10-11 to 2014-10-12 08:00-12:00, 13:00-17:00, 2014-10-25 08:00-12:00, 13:00-17:00, 2014-11-01 08:00-12:00, 13:00-17:00, 2014-11-15 to 2014-11-16 08:00-12:00, 13:00-17:00, 2015-01-10 08:00-12:00, 13:00-17:00.

## Resources

| Resource | Unit | Rate | Cost per use |
| --- | --- | --- | --- |
| Network Administrators |  | 24 |  |
| LAN Cabling Contractors |  |  | 100 |
| Finance Officer |  | 45 |  |
| Database Developer |  | 33 |  |
| Software Engineer/Installer |  | 31.25 |  |
| Human Resource Officer |  | 23 |  |
| Cisco Server | Networking Device |  | 10000 |
| MS Office Small Business | Software |  | 150 |
| Vmware Software | Software |  | 5200 |
| Desktop Computer Suites | Computers |  | 1400 |
| Printer | Printer |  | 3200 |
| Cisco Switch | Networking Device |  | 792 |
| Project Facilitator |  | 33 |  |
| CatV Cabling | Cables | 186 |  |
| Fiber Cabling | Cables | 230 |  |
| Coaxial Cabling | Cables | 150 |  |
| Project Manager |  | 37 |  |
| Cisco Router | Networking Device |  | 1200 |
| Windows Server 2012R2 | Software |  | 546 |
| Risk Manager |  | 33 |  |
| Sponsor |  |  |  |
| Stakeholders |  |  |  |
| Server Rack Mountable | Networking Hardware |  | 500 |
| Quality Control Officer |  | 22 |  |
| Security Consultant |  | 24 |  |
| IT Trainer |  | 50 |  |
| Training Facility | Training Room |  | 500 |

## Schedule

| ID | WBS | Task | Type | Duration | Start | Finish | Predecessors | Total slack | Free slack | Resources | Work | Cost |
| --- | --- | --- | --- | --- | --- | --- | --- | --- | --- | --- | --- | --- |
| 1 | 1 | Commence Project | milestone | 0d | 2014-09-08 | 2014-09-08 |  | 0d |  | Stakeholders [10%] |  |  |
| 2 | 2 | Interview the client |  | 3h | 2014-09-08 | 2014-09-08 | 1 | 0d |  | Project Manager; Sponsor | 6h | 111 |
| 3 | 3 | **Conduct Project Kickoff Meeting** |  | 1.12d | 2014-09-08 | 2014-09-09 |  | 0d |  | Project Manager [10%]; Stakeholders [10%] | 6.95h | 219.85 |
| 4 | 3.1 | **Brief Project Proposal to Management** |  | 1.12d | 2014-09-08 | 2014-09-09 |  | 0d |  | Project Manager [5%] | 5.15h | 186.55 |
| 5 | 3.1.1 | Conduct Powerpoint presentation |  | 1h | 2014-09-08 | 2014-09-08 | 1 | 1d |  | Project Facilitator | 1h | 33 |
| 6 | 3.1.2 | Brief Charter |  | 1h | 2014-09-08 | 2014-09-08 | 2 | 0d |  | Project Manager | 1h | 37 |
| 7 | 3.1.3 | **Acquire sponsor and stakeholder support** |  | 0.62d | 2014-09-08 | 2014-09-09 | 6 | 0d |  | Project Manager [10%] | 2.7h | 99.9 |
| 8 | 3.1.3.1 | Answer sponsor questions |  | 1h | 2014-09-08 | 2014-09-08 | 6 | 0d |  | Project Manager | 1h | 37 |
| 9 | 3.1.3.2 | Answer stakeholder questions |  | 1h | 2014-09-08 | 2014-09-08 | 6 | 0d |  | Project Manager | 1h | 37 |
| 10 | 3.1.3.3 | Acquires signatures on project document |  | 4h | 2014-09-08 | 2014-09-09 | 8, 9 | 0d |  | Project Manager [5%] | 0.2h | 7.4 |
| 11 | 4 | **Identify project team** |  | 10.5d | 2014-09-09 | 2014-09-19 | 4 | 0d |  | Project Manager [5%] | 47.4h | 813.6 |
| 12 | 4.1 | **Select team members** |  | 10.5d | 2014-09-09 | 2014-09-19 | 7 | 0d |  | Project Manager [5%]; Stakeholders [10%]; Sponsor [10%] | 43.2h | 658.2 |
| 13 | 4.1.1 | Review corporate roster |  | 12h | 2014-09-09 | 2014-09-10 | 1 | 9d |  | Human Resource Officer [25%] | 3h | 69 |
| 14 | 4.1.2 | Make list of candidates |  | 12h | 2014-09-09 | 2014-09-10 | 1 | 0d |  | Human Resource Officer [25%] | 3h | 69 |
| 15 | 4.1.3 | Conduct background check |  | 48h | 2014-09-10 | 2014-09-16 | 14 | 0d |  | Human Resource Officer [25%] | 12h | 276 |
| 16 | 4.1.4 | Conduct interviews |  | 8h | 2014-09-16 | 2014-09-17 | 15 | 0d |  | Project Manager [10%] | 0.8h | 29.6 |
| 17 | 4.1.5 | Approve members |  | 16h | 2014-09-17 | 2014-09-19 | 16 | 0d |  | Project Manager [10%]; Stakeholders [10%]; Sponsor [20%] | 3.4h | 59.2 |
| 18 | 5 | **Develop Project Infrastructure** |  | 2d | 2014-09-19 | 2014-09-22 | 17 | 0d |  | Project Manager [5%] | 13.6h | 324 |
| 19 | 5.1 | **Determine roles** |  | 2d | 2014-09-19 | 2014-09-22 |  | 0d |  | Human Resource Officer [50%] | 12.8h | 294.4 |
| 20 | 5.1.1 | Make list of required roles |  | 16h | 2014-09-19 | 2014-09-22 | 6 | 110.12d |  | Human Resource Officer [10%] | 1.6h | 36.8 |
| 21 | 5.1.2 | Analyze member abilities |  | 16h | 2014-09-19 | 2014-09-22 | 17 | 110.12d |  | Human Resource Officer [10%] | 1.6h | 36.8 |
| 22 | 5.1.3 | Assign roles to members |  | 16h | 2014-09-19 | 2014-09-22 | 17, 11 | 0d |  | Human Resource Officer [10%] | 1.6h | 36.8 |
| 23 | 6 | **Create schedule** |  | 1d | 2014-09-22 | 2014-09-23 | 18 | 110.12d |  | Project Facilitator [1%] | 15.04h | 462.5 |
| 24 | 6.1 | **Detemine required events** |  | 0.75d | 2014-09-22 | 2014-09-23 |  | 110.12d | 0d | Project Facilitator [1%] | 8.76h | 238.46 |
| 25 | 6.1.1 | Make list of required events |  | 6h | 2014-09-22 | 2014-09-23 | 6 | 110.12d |  | Project Facilitator [50%] | 3h | 99 |
| 26 | 6.1.2 | Review list of required events |  | 3h | 2014-09-22 | 2014-09-22 | 6 | 110.5d |  | Project Manager; Database Developer [10%]; Network Administrators [10%]; Software Engineer/Installer [10%] | 3.9h | 137.47 |
| 27 | 6.1.3 | Approve list of events |  | 6h | 2014-09-22 | 2014-09-23 | 6 | 110.12d |  | Sponsor [20%]; Stakeholders [10%] | 1.8h |  |

Notes:
- 2: Initial interview with the client will allow us to create the powerpoint presentation and the brief charter for the kick-off meeting.

| ID | WBS | Task | Duration | Start | Finish | Predecessors | Total slack | Free slack | Resources | Work | Cost |
| --- | --- | --- | --- | --- | --- | --- | --- | --- | --- | --- | --- |
| 28 | 6.2 | **Determine task load** | 0.25d | 2014-09-23 | 2014-09-23 | 24 | 110.12d |  | Project Manager [10%] | 6.2h | 221.4 |
| 29 | 6.2.1 | Determine areas of reponsibility | 2h | 2014-09-23 | 2014-09-23 | 22 | 110.12d |  | Project Facilitator | 2h | 66 |
| 30 | 6.2.2 | Assign Action Officers | 2h | 2014-09-23 | 2014-09-23 | 17, 22 | 110.12d |  | Project Manager | 2h | 74 |
| 31 | 6.2.3 | Assign tasks | 2h | 2014-09-23 | 2014-09-23 | 19 | 110.12d |  | Project Manager | 2h | 74 |
| 32 | 7 | **Create Policies** | 5.75d | 2014-09-09 | 2014-09-14 |  | 3.75d | 0d | Project Manager [10%] | 34.5h | 1,162.9 |
| 33 | 7.1 | **Determine value of assets** | 3.5d | 2014-09-09 | 2014-09-12 |  | 3.75d | 0d | Finance Officer [10%] | 6.2h | 279 |
| 34 | 7.1.1 | Make list of assets | 16h | 2014-09-09 | 2014-09-11 | 3 | 3.75d | 0d | Finance Officer [10%] | 1.6h | 72 |
| 35 | 7.1.2 | Prioritize list of assets | 6h | 2014-09-11 | 2014-09-11 | 34 | 3.75d | 0d | Finance Officer [10%] | 0.6h | 27 |
| 36 | 7.1.3 | Determine qualitative value of assets | 6h | 2014-09-11 | 2014-09-12 | 35 | 3.75d |  | Finance Officer [10%] | 0.6h | 27 |
| 37 | 7.1.4 | Determine quantitative value of assets | 6h | 2014-09-11 | 2014-09-12 | 35 | 3.75d |  | Finance Officer [10%] | 0.6h | 27 |
| 38 | 7.2 | **Determine risks** | 1.5d | 2014-09-12 | 2014-09-14 | 33 | 3.75d | 0d | Risk Manager [10%] | 2.4h | 79.2 |
| 39 | 7.2.1 | Determine risks to organization | 6h | 2014-09-12 | 2014-09-13 | 3 | 3.75d | 0d | Risk Manager [10%] | 0.6h | 19.8 |
| 40 | 7.2.2 | Determine risks to project | 6h | 2014-09-13 | 2014-09-14 | 39 | 3.75d |  | Risk Manager [10%] | 0.6h | 19.8 |
| 41 | 7.3 | **Determine risk countermeasures** | 0.75d | 2014-09-14 | 2014-09-14 | 38 | 3.75d |  | Risk Manager [10%] | 1.8h | 59.4 |
| 42 | 7.3.1 | Develop physical controls | 6h | 2014-09-14 | 2014-09-14 | 38 | 3.75d |  | Risk Manager [10%] | 0.6h | 19.8 |
| 43 | 7.3.2 | Develop technical controls | 6h | 2014-09-14 | 2014-09-14 | 38 | 3.75d |  | Risk Manager [10%] | 0.6h | 19.8 |
| 44 | 7.4 | **Develop or acquire high-level policy** | 3d | 2014-09-09 | 2014-09-12 |  | 5.75d | 0d | Project Manager [1%] | 12.24h | 404.88 |
| 45 | 7.4.1 | Find Corporate Policy document | 6h | 2014-09-09 | 2014-09-09 | 3 | 5.75d | 0d | Project Facilitator [50%] | 3h | 99 |
| 46 | 7.4.2 | Review documents | 6h | 2014-09-09 | 2014-09-10 | 45 | 5.75d | 0d | Project Facilitator [50%] | 3h | 99 |
| 47 | 7.4.3 | Develop or review Security Policy | 12h | 2014-09-10 | 2014-09-12 | 46 | 5.75d | 0d | Project Facilitator [50%] | 6h | 198 |
| 48 | 7.5 | **Develop low-level policies based on high-level policy** | 0.75d | 2014-09-12 | 2014-09-12 | 44 | 5.75d |  | Project Manager [1%] | 7.26h | 170.22 |
| 49 | 7.5.1 | **Develop procedures** | 0.75d | 2014-09-12 | 2014-09-12 | 47 | 5.75d |  | Project Manager [10%] | 7.2h | 168 |
| 50 | 7.5.1.1 | Develop administrative procedures | 6h | 2014-09-12 | 2014-09-12 | 3, 44 | 5.75d |  | Human Resource Officer [10%] | 0.6h | 13.8 |
| 51 | 7.5.1.2 | Develop technical/logical procedures | 6h | 2014-09-12 | 2014-09-12 | 3, 44 | 5.75d |  | Quality Control Officer | 6h | 132 |

| ID | WBS | Task | Duration | Start | Finish | Predecessors | Total slack | Free slack | Resources | Work | Cost |
| --- | --- | --- | --- | --- | --- | --- | --- | --- | --- | --- | --- |
| 52 | 8 | **Conduct research** | 8.25d | 2014-09-14 | 2014-09-24 | 32 | 0d |  | Project Facilitator [1%] | 19.32h | 637.56 |
| 53 | 8.1 | **Determine research areas** | 8.25d | 2014-09-14 | 2014-09-24 |  | 0d |  | Project Facilitator [1%] | 18.66h | 615.78 |
| 54 | 8.1.1 | Make list of required research | 12h | 2014-09-14 | 2014-09-16 | 3 | 3.75d | 0d | Project Facilitator [50%] | 6h | 198 |
| 55 | 8.1.2 | Determine best fit for research tasks | 12h | 2014-09-16 | 2014-09-17 | 54 | 3.75d |  | Project Facilitator [50%] | 6h | 198 |
| 56 | 8.1.3 | Assign research tasks | 12h | 2014-09-22 | 2014-09-24 | 22, 55 | 0d |  | Project Facilitator [50%] | 6h | 198 |
| 57 | 9 | **Conduct planning** | 9.62d | 2014-09-24 | 2014-10-07 | 53 | 0d |  | Project Manager [1%] | 87.44h | 2,979.42 |
| 58 | 9.1 | **Develop PM plan** | 2.45d | 2014-09-24 | 2014-09-26 |  | 1.05d |  | Project Manager [1%] | 16.38h | 570.47 |
| 59 | 9.1.1 | Meet with members | 4h | 2014-09-24 | 2014-09-24 | 22 | 1.05d | 0d | Project Manager [50%]; Project Facilitator [50%]; Quality Control Officer [50%]; Finance Officer [50%] | 4.22h | 162 |
| 60 | 9.1.2 | Draft plan | 4h | 2014-09-24 | 2014-09-25 | 59 | 1.05d | 0d | Project Manager [25%] | 1h | 37 |
| 61 | 9.1.3 | Review plan | 4h | 2014-09-25 | 2014-09-25 | 60 | 1.05d | 0d | Project Manager [50%]; Risk Manager [50%]; Project Facilitator [50%] | 4h | 140 |
| 62 | 9.1.4 | **Get support for plan** | 0.75d | 2014-09-25 | 2014-09-26 | 61 | 1.05d |  | Project Manager [1%] | 6.96h | 224.22 |
| 63 | 9.1.4.1 | Get sponsor support in writing | 3h | 2014-09-25 | 2014-09-26 | 59 | 1.05d | 0d | Project Manager; Sponsor [20%] | 3.6h | 111 |
| 64 | 9.1.4.2 | Get stakeholder support in writing | 3h | 2014-09-26 | 2014-09-26 | 63 | 1.05d |  | Project Manager; Stakeholders [10%] | 3.3h | 111 |
| 65 | 9.2 | **Determine requirements** | 3.5d | 2014-09-24 | 2014-09-29 |  | 0d |  | Project Manager [1%] | 42.9h | 1,381 |
| 66 | 9.2.1 | **Determine internal requirements** | 1.5d | 2014-09-24 | 2014-09-25 |  | 0d |  | Project Manager [1%] | 13.02h | 387.44 |
| 67 | 9.2.1.1 | Gather requirements from sponsor | 3h | 2014-09-24 | 2014-09-24 | 3 | 1.12d |  | Project Manager [50%]; Sponsor [50%] | 3h | 55.5 |
| 68 | 9.2.1.2 | Gather requirements from stakeholder | 4h | 2014-09-24 | 2014-09-24 | 3 | 1d |  | Project Manager [50%]; Stakeholders [10%] | 1.9h | 55.5 |
| 69 | 9.2.1.3 | Gather requiremnents from department | 4h | 2014-09-24 | 2014-09-24 | 3 | 1d |  | Project Manager [50%] | 2h | 74 |
| 70 | 9.2.1.4 | Take input from team members | 12h | 2014-09-24 | 2014-09-25 | 3 | 0d |  | Project Facilitator [50%] | 6h | 198 |
| 71 | 9.2.2 | **Determine external requirements** | 2d | 2014-09-25 | 2014-09-29 | 66 | 0d |  | Project Manager [10%] | 29.6h | 983.2 |
| 72 | 9.2.2.1 | Make list of vendors | 6h | 2014-09-25 | 2014-09-26 | 52 | 1.25d |  | Project Facilitator | 6h | 198 |
| 73 | 9.2.2.2 | Get quotes from vendor | 2d | 2014-09-25 | 2014-09-29 | 52 | 0d |  | Project Facilitator | 16h | 528 |
| 74 | 9.2.2.3 | Consolidate external requirements | 6h | 2014-09-25 | 2014-09-26 | 52 | 1.25d |  | Project Facilitator | 6h | 198 |
| 75 | 9.3 | **Define the scope of project** | 0.38d | 2014-09-29 | 2014-09-29 |  | 0d |  | Project Manager [5%] | 0.39h | 13.26 |
| 76 | 9.3.1 | **Determine start and end points** | 0.38d | 2014-09-29 | 2014-09-29 | 66, 71 | 0d |  | Project Manager [5%] | 0.24h | 7.71 |
| 77 | 9.3.1.1 | Determine affected equipment | 3h | 2014-09-29 | 2014-09-29 | 58 | 0d |  | Network Administrators [1%] | 0.03h | 0.72 |
| 78 | 9.3.1.2 | Determine affected services | 3h | 2014-09-29 | 2014-09-29 | 58 | 0d |  | Network Administrators [1%] | 0.03h | 0.72 |
| 79 | 9.3.1.3 | Determine affected users | 3h | 2014-09-29 | 2014-09-29 | 58 | 0d |  | Network Administrators [1%] | 0.03h | 0.72 |

| ID | WBS | Task | Type | Duration | Start | Finish | Predecessors | Total slack | Free slack | Resources | Work | Cost |
| --- | --- | --- | --- | --- | --- | --- | --- | --- | --- | --- | --- | --- |
| 80 | 9.4 | **Determine budget** |  | 5.75d | 2014-09-30 | 2014-10-07 | 75 | 0d |  | Finance Officer [5%] | 27h | 986.2 |
| 81 | 9.4.1 | **Determine equipment costs** |  | 1.75d | 2014-09-30 | 2014-10-01 |  | 0d |  | Finance Officer [5%] | 6.3h | 283.5 |
| 82 | 9.4.1.1 | List equipment costs |  | 7h | 2014-09-30 | 2014-09-30 | 3, 52, 65 | 0d |  | Finance Officer [40%] | 2.8h | 126 |
| 83 | 9.4.1.2 | Total equipment costs |  | 7h | 2014-09-30 | 2014-10-01 | 82 | 0d |  | Finance Officer [40%] | 2.8h | 126 |
| 84 | 9.4.2 | **Determine labor costs** |  | 4d | 2014-10-01 | 2014-10-07 | 81 | 0d |  | Human Resource Officer [5%] | 18.4h | 599.2 |
| 85 | 9.4.2.1 | **List labor costs** |  | 2d | 2014-10-01 | 2014-10-03 | 3, 52, 65 | 0d |  | Human Resource Officer [5%] | 8.8h | 202.4 |
| 86 | 9.4.2.1.1 | Hire LAN Cabling Contractors |  | 2d | 2014-10-01 | 2014-10-03 | 75 | 0d |  | Human Resource Officer [50%] | 8h | 184 |
| 87 | 9.4.2.2 | Total equipment costs |  | 2d | 2014-10-03 | 2014-10-07 | 86 | 0d |  | Finance Officer [50%] | 8h | 360 |
| 88 | 9.4.2.3 | Phase 1 Completed | milestone | 0d | 2014-10-07 | 2014-10-07 | 87 | 0d |  | Quality Control Officer |  |  |
| 89 | 10 | **Execute the project** |  | 82d? | 2014-10-07 | 2015-01-20 | 88, 84 | 0d |  | Project Manager [25%] | 766.48h | 45,324.52 |
| 90 | 10.1 | **Conduct Building Area Assessment** |  | 28d? | 2014-10-07 | 2014-11-10 |  | 0d |  | Project Facilitator [50%] | 197.2h | 6,868 |
| 91 | 10.1.1 | **Assess Building 1** |  | 2d | 2014-10-07 | 2014-10-09 |  | 0d |  | Network Administrators [5%]; LAN Cabling Contractors | 1.6h | 238.4 |
| 92 | 10.1.1.1 | Identify Network Cable Run |  | 2d | 2014-10-07 | 2014-10-09 | 86 | 0d |  | Network Administrators [5%]; LAN Cabling Contractors | 0.8h | 119.2 |
| 93 | 10.1.2 | **Assess Building 2** |  | 2d | 2014-10-09 | 2014-10-11 | 91 | 0d |  | Network Administrators [5%]; LAN Cabling Contractors | 1.6h | 238.4 |
| 94 | 10.1.2.1 | Identify Connection to Building One Network |  | 2d | 2014-10-09 | 2014-10-11 | 92 | 0d |  | Network Administrators [5%]; LAN Cabling Contractors | 0.8h | 119.2 |
| 95 | 10.1.3 | **Assess Risk** |  | 13d | 2014-10-11 | 2014-10-27 | 93 | 11d |  | Risk Manager [5%] | 20.8h | 686.4 |
| 96 | 10.1.3.1 | **Identify Risk** |  | 4d | 2014-10-11 | 2014-10-15 |  | 11d | 0d | Risk Manager [5%] | 4.8h | 158.4 |
| 97 | 10.1.3.1.1 | Tailor risk assessment questionaire |  | 2d | 2014-10-11 | 2014-10-13 | 93 | 11d | 0d | Risk Manager [10%] | 1.6h | 52.8 |
| 98 | 10.1.3.1.2 | Identify known risk |  | 2d | 2014-10-13 | 2014-10-15 | 97 | 11d |  | Risk Manager [10%] | 1.6h | 52.8 |
| 99 | 10.1.3.2 | **Analyze Risk** |  | 3d | 2014-10-15 | 2014-10-20 | 96 | 11d | 0d | Risk Manager [5%] | 3.6h | 118.8 |
| 100 | 10.1.3.2.1 | Rate each risk based on questionaire (H, M, L) |  | 1d | 2014-10-15 | 2014-10-16 | 96 | 11d | 0d | Risk Manager [10%] | 0.8h | 26.4 |
| 101 | 10.1.3.2.2 | Select highest risk |  | 1d | 2014-10-16 | 2014-10-17 | 100 | 11d | 0d | Risk Manager [10%] | 0.8h | 26.4 |
| 102 | 10.1.3.2.3 | Document the category, description & impact to risk response plan |  | 1d | 2014-10-17 | 2014-10-20 | 101 | 11d |  | Risk Manager [10%] | 0.8h | 26.4 |
| 103 | 10.1.3.3 | **Response Planning** |  | 6d | 2014-10-20 | 2014-10-27 | 99 | 11d |  | Risk Manager [5%] | 7.2h | 237.6 |
| 104 | 10.1.3.3.1 | Consult risk assessment |  | 2d | 2014-10-20 | 2014-10-22 | 99 | 11d | 0d | Risk Manager [10%] | 1.6h | 52.8 |
| 105 | 10.1.3.3.2 | Establish risk response actions |  | 3d | 2014-10-22 | 2014-10-25 | 104 | 11d | 0d | Risk Manager [10%] | 2.4h | 79.2 |
| 106 | 10.1.3.3.3 | Schedule actions |  | 1d | 2014-10-25 | 2014-10-27 | 105 | 11d |  | Risk Manager [10%] | 0.8h | 26.4 |

| ID | WBS | Task | Type | Duration | Start | Finish | Predecessors | Total slack | Free slack | Constraint | Resources | Work | Cost |
| --- | --- | --- | --- | --- | --- | --- | --- | --- | --- | --- | --- | --- | --- |
| 107 | 10.1.4 | **Conduct Interal Office Space Assessment** |  | 24d? | 2014-10-11 | 2014-11-10 | 93 | 0d |  |  | Project Facilitator [10%] | 61.2h | 2,008.8 |
| 108 | 10.1.4.1 | Conduct Interal Office Space Assessment | milestone | 0d? | 2014-10-11 | 2014-10-11 |  | 0d |  | must start on 2014-10-11 |  |  |  |
| 109 | 10.1.4.2 | Conduct Interal Office Space Assessment | milestone | 0d? | 2014-11-10 | 2014-11-10 |  | 0d |  | must finish on 2014-11-10 |  |  |  |
| 110 | 10.1.4.3 | Designate Computer Suite Placement |  | 14d | 2014-10-11 | 2014-10-28 | 93 | 0d |  |  | Project Facilitator [20%] | 22.4h | 739.2 |
| 111 | 10.1.4.4 | Designate Multifunction Device Placement |  | 10d | 2014-10-28 | 2014-11-10 | 110 | 0d |  |  | Project Facilitator [20%] | 16h | 528 |
| 112 | 10.1.4.5 | **Indentify Server Rack Location** |  | 3d? | 2014-10-11 | 2014-10-14 | 91 | 0d |  |  | Project Facilitator [10%] | 3.6h | 108 |
| 113 | 10.1.4.5.1 | Indentify Server Rack Location | milestone | 0d? | 2014-10-11 | 2014-10-11 |  | 0d |  | must start on 2014-10-11 |  |  |  |
| 114 | 10.1.4.5.2 | Indentify Server Rack Location | milestone | 0d? | 2014-10-14 | 2014-10-14 |  | 0d |  | must finish on 2014-10-14 |  |  |  |
| 115 | 10.1.4.5.3 | Identify Climate Controlled Room |  | 1d | 2014-10-11 | 2014-10-12 | 91 | 21d | 0d |  | Network Administrators [5%] | 0.4h | 9.6 |
| 116 | 10.1.4.5.4 | Upgrade closet |  | 2d | 2014-10-12 | 2014-10-14 | 115 | 21d |  |  | Network Administrators [5%] | 0.8h | 19.2 |
| 117 | 10.2 | **Acquire equipment** |  | 36d | 2014-11-10 | 2014-12-26 | 90 | 0d |  |  | Finance Officer [10%] | 273.28h | 27,959.52 |
| 118 | 10.2.1 | **IT Procurement** |  | 15d | 2014-11-10 | 2014-11-27 |  | 0d |  |  | Finance Officer [10%] | 64h | 2,880 |
| 119 | 10.2.1.1 | Purchase Servers |  | 5d | 2014-11-10 | 2014-11-15 | 88 | 5d | 0d |  | Finance Officer [10%] | 4h | 180 |
| 120 | 10.2.1.2 | Purchase Desktop Suite |  | 5d | 2014-11-10 | 2014-11-15 | 110 | 5d | 0d |  | Finance Officer [10%] | 4h | 180 |
| 121 | 10.2.1.3 | Purchase Printers |  | 5d | 2014-11-10 | 2014-11-15 | 110 | 10d |  |  | Finance Officer [10%] | 4h | 180 |
| 122 | 10.2.1.4 | **Purchase Software** |  | 5d | 2014-11-15 | 2014-11-20 | 119, 120 | 5d |  |  | Finance Officer [10%] | 16h | 720 |
| 123 | 10.2.1.4.1 | Procure MS Office Small Business 2013 |  | 5d | 2014-11-15 | 2014-11-20 | 119 | 5d |  |  | Finance Officer [10%] | 4h | 180 |
| 124 | 10.2.1.4.2 | Procure Vmware Licensing |  | 5d | 2014-11-15 | 2014-11-20 | 119 | 5d |  |  | Finance Officer [10%] | 4h | 180 |
| 125 | 10.2.1.4.3 | Procure Server 2012R2 |  | 5d | 2014-11-15 | 2014-11-20 | 119 | 5d |  |  | Finance Officer [10%] | 4h | 180 |
| 126 | 10.2.1.5 | **Purchase Network Equipment** |  | 15d | 2014-11-10 | 2014-11-27 | 112 | 0d |  |  | Finance Officer [10%] | 24h | 1,080 |
| 127 | 10.2.1.5.1 | Purchase Server Rack Mounting Hardware |  | 5d | 2014-11-10 | 2014-11-15 | 112 | 0d |  |  | Finance Officer [10%] | 4h | 180 |
| 128 | 10.2.1.5.2 | Purchase Router |  | 5d | 2014-11-15 | 2014-11-20 | 127 | 0d |  |  | Finance Officer [10%] | 4h | 180 |
| 129 | 10.2.1.5.3 | Purchase Switches |  | 5d | 2014-11-20 | 2014-11-27 | 128 | 0d |  |  | Finance Officer [10%] | 4h | 180 |
| 130 | 10.2.2 | **Receive equipment** |  | 21d | 2014-11-27 | 2014-12-26 | 118 | 0d |  |  | Project Facilitator | 180.48h | 23,783.52 |
| 131 | 10.2.2.1 | Install rack mountable |  | 1d | 2014-11-27 | 2014-11-28 | 116, 126 | 0d |  |  | Server Rack Mountable [2 Networking Hardware]; Network Administrators [5%] | 0.4h | 509.6 |

| ID | WBS | Task | Type | Duration | Start | Finish | Predecessors | Total slack | Free slack | Constraint | Resources | Work | Cost |
| --- | --- | --- | --- | --- | --- | --- | --- | --- | --- | --- | --- | --- | --- |
| 132 | 10.2.2.2 | **Configure Internal LAN** |  | 20d | 2014-11-28 | 2014-12-26 | 131 | 0d |  |  | CatV Cabling [1 Cables]; Fiber Cabling [1 Cables]; LAN Cabling Contractors; Network Administrators [5%] | 12.08h | 17,729.92 |
| 133 | 10.2.2.2.1 | **Run Network Cables** |  | 20d | 2014-11-28 | 2014-12-26 | 126 | 0d |  |  | LAN Cabling Contractors |  | 386 |
| 134 | 10.2.2.2.1.1 | Add Network Ports |  | 4w | 2014-11-28 | 2014-12-26 | 129 | 0d |  |  | CatV Cabling [1 Cables]; LAN Cabling Contractors |  | 286 |
| 135 | 10.2.2.2.2 | **Complete Server Configuration** |  | 3d | 2014-11-28 | 2014-12-03 |  | 0d |  |  | Cisco Server [1 Networking Device]; Cisco Switch [1 Networking Device] | 4.08h | 16,635.92 |
| 136 | 10.2.2.2.2.1 | **Create Virtual Servers** |  | 3d | 2014-11-28 | 2014-12-03 | 124 | 0d |  |  | Network Administrators [5%] | 4.08h | 5,843.92 |
| 137 | 10.2.2.2.2.1.1 | Install Servers |  | 3d | 2014-11-28 | 2014-12-03 |  | 0d |  | must start on 2014-11-28 | Network Administrators [1%] | 0.24h | 5.76 |
| 138 | 10.2.2.2.2.1.2 | Install Vmware |  | 3d | 2014-11-28 | 2014-12-03 |  | 0d |  | must finish on 2014-12-03 | Network Administrators [1%]; Vmware Software [1 Software] | 0.24h | 5,205.76 |
| 139 | 10.2.2.2.2.1.3 | Install Server 2012R2 |  | 3d | 2014-11-28 | 2014-12-03 | 124 | 17d |  |  | Network Administrators [5%]; Windows Server 2012R2 [1 Software] | 1.2h | 574.8 |
| 140 | 10.2.2.2.2.1.4 | Configure Server |  | 3d | 2014-11-28 | 2014-12-03 | 124 | 17d |  |  | Network Administrators [5%] | 1.2h | 28.8 |
| 141 | 10.3 | **Install equiment** |  | 18d | 2014-12-26 | 2015-01-20 | 135 | 0d |  |  | Database Developer [15%] | 132h | 4,429 |
| 142 | 10.3.1 | **Create Administrative System** |  | 18d | 2014-12-26 | 2015-01-20 | 140 | 0d |  |  | Database Developer [15%] | 110.4h | 3,716.2 |
| 143 | 10.3.1.1 | **Configure Patient Database** |  | 18d | 2014-12-26 | 2015-01-20 | 63 | 0d |  |  | Database Developer [20%] | 88.8h | 3,003.4 |
| 144 | 10.3.1.1.1 | Install MS Office Small Business |  | 2w | 2014-12-26 | 2015-01-09 | 130 | 0d |  |  | Software Engineer/Installer [50%]; MS Office Small Business [1 Software] | 40h | 1,400 |
| 145 | 10.3.1.1.2 | **Install MS SharePoint** |  | 1d | 2015-01-09 | 2015-01-10 | 144 | 0d |  |  | Software Engineer/Installer [50%] | 6h | 191 |
| 146 | 10.3.1.1.2.1 | Link to Internal Database |  | 1d | 2015-01-09 | 2015-01-10 | 130 | 0d |  |  | Database Developer [25%] | 2h | 66 |
| 147 | 10.3.1.1.3 | Import Patient Information |  | 7d | 2015-01-10 | 2015-01-20 | 145 | 0d |  |  | Database Developer [25%] | 14h | 462 |
| 148 | 10.3.1.1.4 | Phase 2 Completed | milestone | 0d | 2015-01-20 | 2015-01-20 | 147 | 0d |  |  | Project Facilitator [1%] |  |  |
| 149 | 11 | **Control and monitor project** |  | 4.88d | 2015-01-20 | 2015-01-27 | 148 | 0d |  |  | Project Manager [1%] | 23.85h | 712.65 |
| 150 | 11.1 | **Control scope** |  | 4.88d | 2015-01-20 | 2015-01-27 |  | 0d |  |  | Project Manager [1%] | 23.46h | 698.22 |
| 151 | 11.1.1 | **Conduct weekly project meetings - Stakeholder** |  | 2.25d | 2015-01-20 | 2015-01-22 | 148 | 2.62d |  |  | Project Manager [1%] | 6.93h | 252.41 |
| 152 | 11.1.1.1 | Conduct meeting with Sponsor/Stakeholders |  | 4h | 2015-01-20 | 2015-01-21 | 148 | 2.62d | 0d |  | Project Manager [25%] | 1h | 37 |
| 153 | 11.1.1.2 | Conduct meeting with project team |  | 4h | 2015-01-21 | 2015-01-21 | 152 | 2.62d | 0d |  | Project Manager [25%] | 1h | 37 |
| 154 | 11.1.1.3 | Ensure risk management plan and risk response plan are implemented |  | 3h | 2015-01-21 | 2015-01-22 | 153 | 2.62d | 0d |  | Risk Manager [10%] | 0.3h | 9.9 |
| 155 | 11.1.1.4 | Maintain risk response plan |  | 3h | 2015-01-22 | 2015-01-22 | 154 | 2.62d | 0d |  | Risk Manager [10%] | 0.3h | 9.9 |
| 156 | 11.1.1.5 | Risk response tracking |  | 4h | 2015-01-22 | 2015-01-22 | 155 | 2.62d |  |  | Risk Manager [10%] | 0.4h | 13.2 |
| 157 | 11.1.1.6 | Conduct weekly project meetings - Stakeholder 1 |  | 3h | 2015-01-20 | 2015-01-21 |  | 4.5d |  | start no earlier than 2014-09-12 | Project Manager [25%] | 0.75h | 27.75 |
| 158 | 11.1.1.7 | Conduct weekly project meetings - Stakeholder 2 |  | 3h | 2015-01-20 | 2015-01-21 |  | 4.5d |  | start no earlier than 2014-09-19 | Project Manager [25%] | 0.75h | 27.75 |
| 159 | 11.1.1.8 | Conduct weekly project meetings - Stakeholder 3 |  | 3h | 2015-01-20 | 2015-01-21 |  | 4.5d |  | start no earlier than 2014-09-26 | Project Manager [25%] | 0.75h | 27.75 |
| 160 | 11.1.1.9 | Conduct weekly project meetings - Stakeholder 4 |  | 3h | 2015-01-20 | 2015-01-21 |  | 4.5d |  | start no earlier than 2014-10-03 | Project Manager [25%] | 0.75h | 27.75 |
| 161 | 11.1.1.10 | Conduct weekly project meetings - Stakeholder 5 |  | 3h | 2015-01-20 | 2015-01-21 |  | 4.5d |  | start no earlier than 2014-10-10 | Project Manager [25%] | 0.75h | 27.75 |

| ID | WBS | Task | Type | Duration | Start | Finish | Predecessors | Total slack | Constraint | Resources | Work | Cost |
| --- | --- | --- | --- | --- | --- | --- | --- | --- | --- | --- | --- | --- |
| 162 | 11.1.2 | **Conduct weekly project meetings - Project Team** |  | 3.38d | 2015-01-20 | 2015-01-26 |  | 0d |  | Project Manager [1%] | 4.02h | 148.74 |
| 163 | 11.1.2.1 | Conduct weekly project meetings - Project Team 1 |  | 15h | 2015-01-20 | 2015-01-22 | 11 | 0d |  | Project Manager [5%] | 0.75h | 27.75 |
| 164 | 11.1.2.2 | Conduct weekly project meetings - Project Team 2 |  | 3h | 2015-01-22 | 2015-01-22 | 163 | 0d | start no earlier than 2014-09-19 | Project Manager [25%] | 0.75h | 27.75 |
| 165 | 11.1.2.3 | Conduct weekly project meetings - Project Team 3 |  | 3h | 2015-01-23 | 2015-01-23 | 164 | 0d |  | Project Manager [25%] | 0.75h | 27.75 |
| 166 | 11.1.2.4 | Conduct weekly project meetings - Project Team 4 |  | 3h | 2015-01-23 | 2015-01-23 | 165 | 0d |  | Project Manager [25%] | 0.75h | 27.75 |
| 167 | 11.1.2.5 | Conduct weekly project meetings - Project Team 5 |  | 3h | 2015-01-23 | 2015-01-26 | 166 | 0d |  | Project Manager [25%] | 0.75h | 27.75 |
| 168 | 11.1.3 | **Test** |  | 1.5d | 2015-01-26 | 2015-01-27 | 162 | 0d |  | Quality Control Officer [1%] | 12.12h | 282.64 |
| 169 | 11.1.3.1 | Define Testing Specifications |  | 1d | 2015-01-26 | 2015-01-27 | 65, 141 | 0d |  | Quality Control Officer [50%] | 4h | 88 |
| 170 | 11.1.3.2 | Test offline network |  | 4h | 2015-01-27 | 2015-01-27 | 169 | 0d |  | Network Administrators [50%]; Security Consultant [50%] | 4h | 96 |
| 171 | 11.1.3.3 | Test online network |  | 4h | 2015-01-27 | 2015-01-27 | 169 | 0d |  | Network Administrators [50%]; Security Consultant [50%] | 4h | 96 |
| 172 | 12 | **Review project status** |  | 1d | 2015-01-27 | 2015-01-28 | 150 | 0d |  | Quality Control Officer [1%] | 5.16h | 113.52 |
| 173 | 12.1 | **Confirm project status** |  | 1d | 2015-01-27 | 2015-01-28 | 168 | 0d |  | Quality Control Officer [1%] | 5.08h | 111.76 |
| 174 | 12.1.1 | Review tests |  | 1d | 2015-01-27 | 2015-01-28 | 168 | 12.12d |  | Quality Control Officer [25%] | 2h | 44 |
| 175 | 12.1.2 | Meet with sponsor |  | 4h | 2015-01-27 | 2015-01-28 | 168 | 12.62d |  | Quality Control Officer [25%] | 1h | 22 |
| 176 | 12.1.3 | Meet with stakeholder |  | 4h | 2015-01-27 | 2015-01-28 | 168 | 12.62d |  | Quality Control Officer [25%] | 1h | 22 |
| 177 | 12.1.4 | Meet with project team |  | 4h | 2015-01-27 | 2015-01-28 | 168 | 0d |  | Quality Control Officer [25%] | 1h | 22 |
| 178 | 12.1.5 | Phase 3 Completed | milestone | 0d | 2015-01-28 | 2015-01-28 | 177 | 0d |  | Quality Control Officer [1%] |  |  |
| 179 | 13 | **Document project** |  | 9d | 2015-01-28 | 2015-02-10 | 178 | 0d |  | Project Facilitator [5%] | 79.2h | 2,613.6 |
| 180 | 13.1 | **Document project milestones** |  | 9d | 2015-01-28 | 2015-02-10 | 178 | 0d |  | Project Facilitator [5%] | 75.6h | 2,494.8 |
| 181 | 13.1.1 | Document Testing |  | 3d | 2015-01-28 | 2015-02-02 | 168 | 0d |  | Project Facilitator | 24h | 792 |
| 182 | 13.1.2 | Document installation |  | 3d | 2015-02-02 | 2015-02-05 | 181 | 0d |  | Project Facilitator | 24h | 792 |
| 183 | 13.1.3 | Document configurations |  | 3d | 2015-02-05 | 2015-02-10 | 182 | 0d |  | Project Facilitator | 24h | 792 |
| 184 | 14 | **Train Veterinarian Staff** |  | 1.5d | 2015-02-10 | 2015-02-11 | 179 | 0d |  | IT Trainer [25%]; Training Facility [1 Training Room] | 5.4h | 2,270 |
| 185 | 14.1 | Train on Basic System Troubleshooting |  | 4h | 2015-02-10 | 2015-02-10 | 183 | 0d |  | IT Trainer [10%]; Training Facility [1 Training Room] | 0.4h | 520 |
| 186 | 14.2 | Train on Application Usage |  | 4h | 2015-02-10 | 2015-02-11 | 185 | 0d |  | IT Trainer [25%]; Training Facility [1 Training Room] | 1h | 550 |
| 187 | 14.3 | Train on Basic Desktop Maintenance |  | 4h | 2015-02-11 | 2015-02-11 | 186 | 0d |  | IT Trainer [25%]; Training Facility [1 Training Room] | 1h | 550 |

Notes:
- 163: Weekly project meetings are held at 10am every Friday.
- 164: Weekly project meetings are held at 10am every Friday.
- 165: Weekly project meetings are held at 10am every Friday.
- 166: Weekly project meetings are held at 10am every Friday.
- 167: Weekly project meetings are held at 10am every Friday.

| ID | WBS | Task | Type | Duration | Start | Finish | Predecessors | Total slack | Resources | Work | Cost |
| --- | --- | --- | --- | --- | --- | --- | --- | --- | --- | --- | --- |
| 188 | 15 | **Close project** |  | 2.12d | 2015-02-11 | 2015-02-13 | 184 | 0d | Project Manager [5%] | 17.85h | 596.45 |
| 189 | 15.1 | Complete project documentation |  | 2d | 2015-02-11 | 2015-02-13 |  | 0d | Project Facilitator | 16h | 528 |
| 190 | 15.2 | Conduct lessons learned meeting |  | 1h | 2015-02-13 | 2015-02-13 | 189 | 0d | Project Manager | 1h | 37 |
| 191 | 16 | Go Live | milestone | 0d | 2015-02-13 | 2015-02-13 | 190 | 0d | Sponsor; Network Administrators; Security Consultant |  |  |
